# CRMC OW Overview

Schedule from GanttProject, 2013-10-01 to 2040-03-31.

## Calendars

- Project calendar: Mon-Sun working.

## Resources

| Resource |
| --- |
| CRMC Fed Con |
| CRMC Cat B |
| BOEM |
| Vineyard Wind |
| Vineyard Wind South |
| Liberty Wind |
| Mayflower Wind |
| Beacon Wind |
| South Fork Wind |
| Revolution Wind |
| Sunrise Wind |
| Bay State Wind |
| Block Island Wind Farm |
| CVOW - Pilot |
| MA CZMA |
| NYSERDA |
| ISO NE |

## Schedule

| ID | WBS | Task | Duration | Start | Finish | Complete |
| --- | --- | --- | --- | --- | --- | --- |
| 1 | 1 | **Block Island Wind Farm** | 7306d | 2016-12-01 | 2036-12-01 |  |
| 2 | 1.1 | operations | 7306d | 2016-12-01 | 2036-12-01 |  |
| 3 | 2 | **Block Island Transmission System** | 7306d | 2016-12-01 | 2036-12-01 |  |
| 4 | 2.1 | operations | 7306d | 2016-12-01 | 2036-12-01 |  |
| 5 | 2.2 | repairs | 1217d | 2019-01-01 | 2022-05-01 |  |
| 6 | 3 | **Vineyard Wind 1** | 9132d | 2015-04-01 | 2040-03-31 |  |
| 7 | 3.1 | **BOEM** | 9132d | 2015-04-01 | 2040-03-31 |  |
| 8 | 3.1.1 | Lease | 9132d | 2015-04-01 | 2040-03-31 |  |
| 9 | 3.1.2 | SAP | 406d | 2017-03-31 | 2018-05-10 |  |
| 10 | 3.1.3 | **COP** | 1209d | 2017-12-19 | 2021-04-10 | 12% |
| 11 | 3.1.3.1 | Application received | 1d | 2017-12-19 | 2017-12-19 |  |
| 12 | 3.1.3.2 | NOI + Scoping | 32d | 2018-03-30 | 2018-04-30 |  |
| 13 | 3.1.3.3 | DEIS NOA + Comments | 47d | 2018-12-07 | 2019-01-22 |  |
| 14 | 3.1.3.4 | Additional DEIS Comments | 15d | 2019-02-08 | 2019-02-22 |  |
| 15 | 3.1.3.5 | SEIS NOA + Comments | 46d | 2020-06-12 | 2020-07-27 |  |
| 16 | 3.1.3.6 | Termination Period | 78d | 2020-12-16 | 2021-03-03 |  |
| 17 | 3.1.3.7 | FEIS NOA | 30d | 2021-03-12 | 2021-04-10 | 100% |
| 18 | 3.1.4 | ROD | 5d | 2021-05-10 | 2021-05-14 |  |
| 19 | 3.1.5 | Decision | 5d | 2021-05-10 | 2021-05-14 |  |
| 20 | 3.2 | **CRMC** | 329d | 2018-04-06 | 2019-02-28 |  |
| 21 | 3.2.1 | **CZMA Federal Consistency** | 329d | 2018-04-06 | 2019-02-28 |  |
| 22 | 3.2.1.1 | Certification filed | 1d | 2018-04-06 | 2018-04-06 |  |
| 23 | 3.2.1.2 | 30 day missing NDI | 30d | 2018-04-06 | 2018-05-05 |  |
| 24 | 3.2.1.3 | 3 month letter | 59d | 2018-05-05 | 2018-07-02 |  |
| 25 | 3.2.1.4 | 6 month decision | 242d | 2018-07-02 | 2019-02-28 |  |

Notes:
- 2: estimated
- 6: Companies: / Vineyard Wind / BOEM Lease: OCS-A 0501 / Plate Capacity Rating (MW): / PPA: 800 MW with MA / Interconnection Point: / WTG Selected: / Foundation Type: Monopile
- 8: Scoping and review of the area omitted. / See notes on the webpage for more details and dates / https://www.boem.gov/sites/default/files/renewable-energy-program/State-Activities/MA/Lease-OCS-A-0501.pdf / Dates were erased so I am using the above to recreate it / preliminary term 1 year / site assessment term 5 years / operations term 25 years
- 9: Submitted: / March 31, 2017 / Revisions: / July 30, 2017 / October 30, 2017 / Final: / November 27, 2017 / BOEM approval: / 5/10/2018 / Duration: / 5 years
- 10: Application received: / 12/19/2017 / Issuance of decision for permit approval: / 5/10/2021 / Original Target date was 7/19/2019
- 16: Terminated in "Web Link", Resumed here: https://www.federalregister.gov/documents/2021/03/03/2021-04392/notice-to-resume-the-preparation-of-a-final-environmental-impact-statement-for-the-construction-and / Termination notice: / In December 2017, Vineyard Wind submitted to BOEM a COP for the Vineyard Wind 1 Project. On December 7, 2018, BOEM published a Draft EIS for the proposed Project. On June 12, 2020, BOEM published a Supplement to the Draft EIS in response to comments from the public and stakeholders requesting an expanded cumulative analysis and an analysis of fishing data previously unavailable to BOEM. A Final EIS was scheduled to be published in the Federal Register on December 11, 2020. However, by way of a letter dated December 1, 2020, Vineyard Wind withdrew the COP “from further review and decision-making by BOEM pursuant to 30 CFR 585.628” to conduct additional technical and logistical reviews associated with the inclusion of the General Electric Haliade-X wind turbine generator into the final project design. Vineyard Wind's December 1, 2020, letter for withdrawal of its COP was made “effectively immediately.” Since the COP has been withdrawn from review and decision-making, there is no longer a proposal for a major federal action awaiting technical and environmental review, nor is there a decision pending before BOEM. See 42 U.S.C. 4332; 40 CFR 1500.1; 1508.1(q), (x). Thus, in light of Vineyard Wind's letter dated December 1, 2020, this notice advises the public that the preparation and completion of an EIS is no longer necessary, and the process is hereby terminated. / Authority: This Notice was prepared under National Environmental Policy Act, as amended (42 U.S.C. 4321 et seq.), and published in accordance with Council on Environmental Quality regulations (40 CFR parts 1500-1508), including sections 1503.1 and 1506.6. / William Yancey Brown, / Chief Environmental Officer, Bureau of Ocean Energy Management.
- 17: No public comment listed at the Federal Register but / https://www.permits.performance.gov/permitting-projects/vineyard-wind / states there was a public review period / I am sticking in 30 days here and can correct later. / I recall Co Operating Agency meetings.
- 18: Initial number from fast 41
- 19: https://www.federalregister.gov/documents/2021/05/14/2021-10192/notice-of-availability-of-a-joint-record-of-decision-for-the-final-environment-impact-statement-for / End date from this URL
- 21: CRMC File number: 2018-04-055
- 22: From Jim's summary sheet
- 23: No letter issued - based on Jim's excel sheet
- 24: Have three months to issue this letter / per Jim's excel sheet
- 25: Per Jim's excel sheet / 5 Stay agreements

| ID | WBS | Task | Duration | Start | Finish |
| --- | --- | --- | --- | --- | --- |
| 26 | 3.3 | **Vineyard Wind** | 7997d | 2018-05-10 | 2040-03-31 |
| 27 | 3.3.1 | Site Assessment Term | 1827d | 2018-05-10 | 2023-05-10 |
| 28 | 3.3.2 | **Biological Surveys** | 1585d | 2020-10-01 | 2025-02-01 |
| 29 | 3.3.2.1 | pre construction | 731d | 2020-10-01 | 2022-10-01 |
| 30 | 3.3.2.2 | during construction | 263d | 2022-05-15 | 2023-02-01 |
| 31 | 3.3.2.3 | post construction | 732d | 2023-02-01 | 2025-02-01 |
| 32 | 3.3.3 | Financial Close | 1d | 2021-09-22 | 2021-09-22 |
| 33 | 3.3.4 | Construction | 427d | 2021-11-18 | 2023-01-18 |
| 34 | 3.3.5 | Operations | 5538d | 2023-02-01 | 2038-03-31 |
| 35 | 3.3.6 | Decomissioning | 731d | 2038-04-01 | 2040-03-31 |
| 36 | 4 | **South Fork Wind** | 9132d | 2013-10-01 | 2038-10-01 |
| 37 | 4.1 | **BOEM** | 9132d | 2013-10-01 | 2038-10-01 |
| 38 | 4.1.1 | **Lease** | 9132d | 2013-10-01 | 2038-10-01 |
| 39 | 4.1.1.1 | OCS-A 0486 | 2366d | 2013-10-01 | 2020-03-23 |
| 40 | 4.1.1.2 | OCS-A 0517 | 6767d | 2020-03-23 | 2038-10-01 |
| 41 | 4.1.2 | SAP | 560d | 2016-04-01 | 2017-10-12 |
| 42 | 4.1.3 | **COP** | 1174d | 2018-06-29 | 2021-09-14 |
| 43 | 4.1.3.1 | Application received | 113d | 2018-06-29 | 2018-10-19 |
| 44 | 4.1.3.2 | NOI + Scoping | 32d | 2018-10-19 | 2018-11-19 |
| 45 | 4.1.3.3 | Pause | 312d | 2019-04-08 | 2020-02-13 |
| 46 | 4.1.3.4 | DEIS NOA + Comments | 50d | 2021-01-04 | 2021-02-22 |
| 47 | 4.1.3.5 | FEIS NOA | 30d | 2021-08-16 | 2021-09-14 |
| 48 | 4.1.4 | ROD | 7d | 2021-11-24 | 2021-11-30 |
| 49 | 4.2 | **CRMC** | 984d | 2018-10-22 | 2021-07-01 |
| 50 | 4.2.1 | **CZMA Federal Consistency** | 984d | 2018-10-22 | 2021-07-01 |
| 51 | 4.2.1.1 | Certification filed | 1d | 2018-10-22 | 2018-10-22 |
| 52 | 4.2.1.2 | 30 Day missing NDI | 30d | 2018-10-22 | 2018-11-20 |
| 53 | 4.2.1.3 | 3 month letter | 64d | 2018-11-20 | 2019-01-22 |
| 54 | 4.2.1.4 | 6 month decision | 898d | 2019-01-16 | 2021-07-01 |

Notes:
- 27: See SAP
- 29: estimated
- 30: estimated
- 31: estimated
- 32: Based on the date of industry news
- 33: Start date based on industry news. / End date not researched just set
- 34: begin date estimated / end date from lease - will change / subtract two years for decommissioning / Decommissioning is based on this date
- 35: based on end of the lease minus two years / they will surely change this
- 36: Companies: / Orsted / Eversource / BOEM Lease(s) / OCS-A 0486 (Originally Deepwater Wind) / OCS-A 0517 (March 2021) / Nameplate Capacity (MW): 130 / PPA: 130 MW with NY
- 39: Preliminary Term = 6 mo / Site assessment term = 5 years / operations term = 25 years / Original end date was October 1, 2038 / But this was clipped in march 2020
- 40: end date of lease retained / https://www.boem.gov/renewable-energy/state-activities/commercial-wind-leasing-offshore-rhode-island-and-massachusetts
- 41: On October 12, 2017, the BOEM approved the Site Assessment Plan (SAP) for Lease OCS-A 0486 (Deepwater Wind New England LLC). The SAP approval allows for the installation of an AXYS FLiDAR 6M™ meteorological buoy within the lease area. For additional information, please find the approved SAP and conditions of approval at the web link. / The SAP was filed on April 1, 2016, with revisions filed in July, September, and November 2016. BOEM determined the SAP was complete on October 7, 2016.
- 43: Deepwater Wind submitted its COP on June 29, 2018. Deepwater Wind submitted updated COPs on May 24, 2019, and February 13, 2020, and July 22, 2020.
- 44: https://www.federalregister.gov/documents/2018/10/19/2018-22880/notice-of-intent-to-prepare-an-environmental-impact-statement-for-deepwater-wind-south-fork-llcs
- 45: I end the pause with the update to the permitting dashboard / On April 8, 2019, the project sponsor requested a project pause in order to provide additional information in their COP. The project pause continued while BOEM conducted an analysis to address public comments regarding cumulative impacts of future offshore wind development. / On January 16, 2020, Deepwater Wind New England, LLC. submitted an application to BOEM to assign 13,700 acres of OCS-A 0486 to Deepwater Wind South Fork, LLC. BOEM approved the assignment on March 23, 2020. The lease area assigned to Deepwater Wind South Fork, LLC now carries the new lease number OCS-A 0517. / On February 13, 2020, the project sponsor submitted an updated COP which changed the turbine layout to address navigational safety issues raised by the commercial fishing industry. The updated COP, lease assignment, and BOEM’s development of a more robust cumulative-impact analysis for offshore wind projects moving forward necessitated additional interagency coordination in developing the permitting timetable. / On August 21, 2020, working with other Federal agencies, BOEM updated the Permitting Dashboard for the South Fork Wind Farm: https://www.permits.performance.gov/permitting-projects/south-fork-wind-farm-and-south-fork-export-cable
- 46: https://www.federalregister.gov/documents/2021/01/08/2021-00100/notice-of-public-meetings-and-of-availability-of-a-draft-environmental-impact-statement-for / the dates in the federal register differ from that on the project website / Jim's date is 1/8/21
- 47: https://www.federalregister.gov/documents/2021/08/20/2021-17829/notice-of-availability-of-a-final-environmental-impact-statement-for-south-fork-wind-llcs-proposed / Federal register date differs again.
- 48: https://www.boem.gov/sites/default/files/documents/renewable-energy/state-activities/Record%20of%20Decision%20South%20Fork_0.pdf
- 50: CRMC File Number 2018-10-082
- 51: Start of CZMA review
- 52: not sure if a letter was actually submitted
- 53: Letter issued on 1/16/2019 (Jim's exel sheet)
- 54: 9 Stay Agreements / Issued on 7/1/2021

| ID | WBS | Task | Duration | Start | Finish | Complete | Resources |
| --- | --- | --- | --- | --- | --- | --- | --- |
| 55 | 4.3 | **South Fork Wind** | 7660d | 2017-10-12 | 2038-10-01 |  |  |
| 56 | 4.3.1 | Site assessment period | 1827d | 2017-10-12 | 2022-10-12 |  |  |
| 57 | 4.3.2 | **Biological Surveys** | 965d | 2021-05-01 | 2023-12-21 |  |  |
| 58 | 4.3.2.1 | pre construction | 731d | 2021-12-21 | 2023-12-21 |  |  |
| 59 | 4.3.2.2 | construction | 1d | 2021-05-01 | 2021-05-01 |  |  |
| 60 | 4.3.2.3 | post construction | 1d | 2021-05-01 | 2021-05-01 |  |  |
| 61 | 4.3.3 | Fincnacial close | 1d | 2021-05-01 | 2021-05-01 |  |  |
| 62 | 4.3.4 | construction | 185d | 2022-05-01 | 2022-11-01 |  |  |
| 63 | 4.3.5 | operations | 5084d | 2022-11-01 | 2036-10-01 |  |  |
| 64 | 4.3.6 | decommissioning | 731d | 2036-10-01 | 2038-10-01 |  |  |
| 65 | 5 | **Revolution Wind** | 2830d | 2015-11-01 | 2023-07-31 | 40% | CRMC Fed Con; CRMC Cat B; BOEM; Revolution Wind |
| 66 | 5.1 | **BOEM** | 2678d | 2016-04-01 | 2023-07-31 | 41% |  |
| 67 | 5.1.1 | SAP | 560d | 2016-04-01 | 2017-10-12 | 100% | BOEM |
| 68 | 5.1.2 | **COP** | 732d | 2021-04-30 | 2023-05-01 |  | BOEM |
| 69 | 5.1.2.1 | NOI Scoping | 30d | 2021-04-30 | 2021-05-29 |  | BOEM |
| 70 | 5.1.2.2 | NOA EIS prep | 732d | 2021-04-30 | 2023-05-01 |  | BOEM |
| 71 | 5.1.3 | ROD | 39d | 2023-03-24 | 2023-05-01 |  | BOEM |
| 72 | 5.1.4 | Decision | 1d | 2023-07-31 | 2023-07-31 |  | BOEM |
| 73 | 5.2 | **CRMC** | 1431d | 2015-11-01 | 2019-10-01 |  |  |
| 74 | 5.2.1 | SAP | 1d | 2019-10-01 | 2019-10-01 |  |  |
| 75 | 5.2.2 | COP | 1d | 2018-11-01 | 2018-11-01 |  |  |
| 76 | 5.2.3 | NOI Scoping | 1d | 2018-11-01 | 2018-11-01 |  |  |
| 77 | 5.2.4 | 30 day review | 1d | 2018-11-01 | 2018-11-01 |  |  |
| 78 | 5.2.5 | **Cooperating Agency Meetings** | 1097d | 2015-11-01 | 2018-11-01 |  |  |
| 79 | 5.2.5.1 | Scoping | 1d | 2018-11-01 | 2018-11-01 |  |  |
| 80 | 5.2.5.2 | Alternates | 1d | 2015-11-01 | 2015-11-01 |  |  |
| 81 | 5.3 | FAB | 1d | 2015-11-01 | 2015-11-01 |  |  |

Notes:
- 56: See SAP
- 62: dates estimated
- 63: estimated from constriction and end of lease - 2 years
- 64: estimated
- 65: There was a lot of changes to the company and lease areas so / Start date from SAP (1) / End date rfom FAST-41 (2) / References: / (1) https://www.boem.gov/Revolution-Wind / Accessed 2021-11-16 / (2) https://www.permits.performance.gov/permitting-project/revolution-wind-farm-project / Accessed 2021-11-16
- 67: 2021-11-16 https://www.boem.gov/Revolution-Wind / The SAP was filed on April 1, 2016, with revisions filed in July, September, and November 2016. BOEM determined the SAP was complete on October 7, 2016. / On October 12, 2017, the Bureau of Ocean Energy Management approved the Site Assessment Plan (SAP) for Lease OCS-A 0486. The SAP approval allows for the installation of an AXYS FLiDAR 6M™ meteorological buoy within the lease area.
- 68: 2021-11-16 https://www.boem.gov/Revolution-Wind / Revolution Wind submitted its COP on March 13, 2020. BOEM will review the COP and approve, disapprove, or approve with modifications the proposed activities.

| ID | WBS | Task | Duration | Start | Finish |
| --- | --- | --- | --- | --- | --- |
| 82 | 5.4 | **Revolution Wind** | 2009d | 2015-11-01 | 2021-05-01 |
| 83 | 5.4.1 | Permitting | 1d | 2015-11-01 | 2015-11-01 |
| 84 | 5.4.2 | G&G Surveys | 1d | 2015-11-01 | 2015-11-01 |
| 85 | 5.4.3 | **Biological Surveys** | 1d | 2021-05-01 | 2021-05-01 |
| 86 | 5.4.3.1 | pre construction | 1d | 2021-05-01 | 2021-05-01 |
| 87 | 5.4.3.2 | construction | 1d | 2021-05-01 | 2021-05-01 |
| 88 | 5.4.3.3 | post construction | 1d | 2021-05-01 | 2021-05-01 |
| 89 | 5.4.4 | Construction | 1d | 2015-11-01 | 2015-11-01 |
| 90 | 5.4.5 | Operations | 1d | 2015-11-01 | 2015-11-01 |
| 91 | 5.4.6 | Decommissioning | 1d | 2015-11-01 | 2015-11-01 |
| 92 | 6 | New England Wind | 1d | 2015-11-01 | 2015-11-01 |
| 93 | 7 | Mayflower Wind | 1d | 2015-11-01 | 2015-11-01 |
| 94 | 8 | Sunrise Wind | 1d | 2015-11-01 | 2015-11-01 |
| 95 | 9 | Bay State Wind | 1d | 2015-11-01 | 2015-11-01 |
| 96 | 10 | Liberty Wind | 1d | 2015-11-01 | 2015-11-01 |
| 97 | 11 | Beacon Wind | 1d | 2015-11-01 | 2015-11-01 |
| 98 | 12 | **Regional Collaboration** | 1d | 2015-11-01 | 2015-11-01 |
| 99 | 12.1 | Fisheries Mitigation | 1d | 2015-11-01 | 2015-11-01 |
| 100 | 12.2 | Align CZMA- DEIS NOA | 1d | 2015-11-01 | 2015-11-01 |
